# SDM-E1_Programacion

Schedule from MS Project, 2021-10-01 to 2023-04-06, costs in $.

## Calendars

- Estándar: Mon-Fri 09:00-13:00, 15:00-19:00; Sat-Sun off.

## Schedule

| ID | WBS | Task | Type | Duration | Start | Finish | Predecessors | Total slack | Free slack | Constraint | Cost |
| --- | --- | --- | --- | --- | --- | --- | --- | --- | --- | --- | --- |
| 1 | 1 | **EDIFICIO STELLA MARINA** |  | 395d | 2021-10-01 | 2023-04-06 |  | 0d |  |  | 8,293,854,420 |
| 2 | 1.1 | INICIO DE PROYECTO | milestone | 0d | 2021-10-01 | 2021-10-01 |  | 0d |  | start no earlier than 2021-10-01 |  |
| 3 | 1.2 | **CONSTRUCCION STELLA MARINA** |  | 395d | 2021-10-01 | 2023-04-06 |  | 0d |  |  | 8,293,854,420 |
| 4 | 1.2.1 | **EDIFICIO** |  | 395d | 2021-10-01 | 2023-04-06 |  | 0d |  |  | 7,473,949,020 |
| 5 | 1.2.1.1 | 1. Preliminares y Fundiciones. |  | 75d | 2021-10-01 | 2022-01-13 | 2SS | 0d |  |  | 105,282,180 |
| 6 | 1.2.1.2 | 3. Cimentación. |  | 45d | 2021-10-22 | 2021-12-23 | 5SS+15d | 0d |  |  | 515,480,220 |
| 7 | 1.2.1.3 | 4. Estructura. |  | 120d | 2021-12-24 | 2022-06-09 | 6 | 0d |  |  | 1,939,725,900 |
| 8 | 1.2.1.4 | 5. Instalaciones Eléctricas. |  | 240d | 2022-02-04 | 2023-01-05 | 10SS | 65d |  |  | 728,012,520 |
| 9 | 1.2.1.5 | 6. Instalaciones Hidráulicas. |  | 240d | 2022-02-04 | 2023-01-05 | 10SS | 65d |  |  | 343,392,480 |
| 10 | 1.2.1.6 | 7. Mampostería no estructural. |  | 90d | 2022-02-04 | 2022-06-09 | 7SS+30d | 0d |  |  | 445,213,800 |
| 11 | 1.2.1.7 | 8. Cubiertas. |  | 15d | 2022-06-21 | 2022-07-11 | 10FS+7d | 193d |  |  | 31,142,520 |
| 12 | 1.2.1.8 | 9. Pañetes y enchapados. |  | 120d | 2022-03-18 | 2022-09-01 | 10SS+30d | 0d |  |  | 353,503,620 |
| 13 | 1.2.1.9 | 10. Pisos. |  | 150d | 2022-06-10 | 2023-01-05 | 17SS+30d | 5d | 0d |  | 421,405,380 |
| 14 | 1.2.1.10 | 11. Carpintería metálica. |  | 150d | 2022-06-10 | 2023-01-05 | 12SS+60d | 65d |  |  | 451,509,120 |
| 15 | 1.2.1.11 | 12. Carpintería de madera y plástico. |  | 150d | 2022-08-12 | 2023-03-09 | 13SS+45d | 20d |  |  | 216,734,400 |
| 16 | 1.2.1.12 | 13. Vidrios, espejos y cerraduras. |  | 60d | 2023-01-06 | 2023-03-30 | 13 | 5d |  |  | 109,275,480 |
| 17 | 1.2.1.13 | 14. Pintura y revestimiento. |  | 200d | 2022-04-29 | 2023-02-02 | 12SS+30d | 0d |  |  | 486,383,940 |
| 18 | 1.2.1.14 | 15. Equipos de baños y cocinas. |  | 75d | 2022-09-02 | 2022-12-15 | 13SS+60d | 80d |  |  | 478,209,420 |
| 19 | 1.2.1.15 | 16. Equipos especiales, mecánicos y accesorios. |  | 60d | 2022-07-01 | 2022-09-22 | 10FS+15d | 140d |  |  | 771,985,800 |
| 20 | 1.2.1.16 | 17. Obras exteriores y/o urbanismo. |  | 30d | 2023-02-03 | 2023-03-16 | 17 | 15d |  |  | 45,236,520 |
| 21 | 1.2.1.17 | 19. Aseo y nomenclatura. |  | 30d | 2023-02-24 | 2023-04-06 | 17FS+15d | 0d |  |  | 31,455,720 |
| 22 | 1.2.1.18 | Fin Edificio | milestone | 0d | 2023-04-06 | 2023-04-06 | 21FF | 0d |  |  |  |
| 23 | 1.2.2 | **GASTOS GENERALES** |  | 395d | 2021-10-01 | 2023-04-06 |  | 0d |  |  | 819,905,400 |
| 24 | 1.2.2.1 | 18. Gastos generales de obra. |  | 395d | 2021-10-01 | 2023-04-06 | 2SS | 0d |  | start no earlier than 2021-06-01 | 819,905,400 |
| 25 | 1.2.2.2 | Fin Gastos generales de obra. | milestone | 0d | 2023-04-06 | 2023-04-06 | 24FF | 0d |  | start no earlier than 2022-03-28 |  |
